# ENTREGA DE LAS DEFENSAS RIBEREÑAS DE LOS RÍOS CAÑETE Y HUAURA (PAQUETE 5)"

Schedule from Primavera P6, 2024-03-01 to 2025-07-30, data date 2024-03-01, costs in PEN.
Must finish by 2025-07-30

## Calendars

- Huara III: Mon-Sat 07:00-16:00; Sun off.

## Resources

| Resource | Group |
| --- | --- |
| SHOTCRETERA | equipment |
| TRACTOR SOBRE ORUGAS CAT D6D | equipment |
| RODILLO LISO VIBRATORIO AUTOPROPULSADO 101-135 HP 10-12TON | labor |
| RETROEXCAVADORA SOBRE LLANTAS 58 HP, 1 Y3 | equipment |
| MOTONIVELADORA 140K | equipment |
| EXCAVADORA CAT 336 | equipment |
| RETROEXCAVADORA SOBRE LLANTAS 94 HP, 1.25 Y3 | equipment |
| RODILLO LISO VIBRATORIO MANUAL 10.8 HP 0.8 -1.1 Ton | equipment |
| CAMION GRUA 20 TON | equipment |
| CAMION MIXER | equipment |
| CARGADOR FRONTAL CAT-966-H | labor |
| CAMION VOLQUETE 15M3 | equipment |
| CAMION VOLQUETE 22M3 | equipment |
| TRACTOR SOBRE ORUGAS CAT D8T | equipment |
| CAMION CISTERNA | labor |
| MARTILLO HIDRAULICO P/EXCAVADORA | equipment |

## Schedule

| ID | WBS | Activity | Type | Duration | Start | Finish | Predecessors | Total float | Free float | Constraint | Cost |
| --- | --- | --- | --- | --- | --- | --- | --- | --- | --- | --- | --- |
|  | 1 | **HUARA III** |  |  | 2024-03-01 | 2025-07-30 |  |  |  |  |  |
|  | 1 | **HITOS** |  |  | 2024-03-01 | 2025-07-30 |  |  |  |  |  |
| A1540 |  | Inicio de obra - Acceso al Sitio | milestone | 0d | 2024-03-01 | 2024-03-01 |  | -0.28d | 0d | start on 2024-03-01 |  |
| A1550 |  | Inicio de Obras Peliminares | milestone | 0d | 2024-03-22 | 2024-03-22 |  | 8.22d | 0d | start on or after 2024-03-22 |  |
| A1560 |  | Inicio de Obras_ Dique Paquete 4 | milestone | 0d | 2024-04-12 | 2024-04-12 |  | 406.22d | 406.5d | start on or after 2024-04-12 |  |
| A1570 |  | Inicio de Obras_Muros Reforzados Paquete 4 | milestone | 0d | 2024-04-12 | 2024-04-12 |  | 84.22d | 0d | start on or after 2024-04-12 |  |
| A1580 |  | Inicio de obras_Reforestación y Paisajismo | milestone | 0d | 2024-04-12 | 2024-04-12 |  | 406.22d | 406.5d | start on or after 2024-04-12 |  |
| A1590 |  | Fin de Obras_Diques Paquete 4 | milestone | 0d | 2024-06-26 | 2024-06-26 |  | 0d | 341.5d | finish on 2024-06-26 |  |
| A1600 |  | Inicio de Obras _Dique Cuenca Alta | milestone | 0d | 2024-06-27 | 2024-06-27 |  | 0.72d | 0d | start on or after 2024-06-27 |  |
| A1610 |  | Fin de Obras_ Dique Cuenca Alta | milestone | 0d | 2024-12-30 | 2024-12-30 |  | 0d | 182.28d | finish on 2024-12-30 |  |
| A1620 |  | Fin de obras_Reforestación y Paisajismo | milestone | 0d | 2025-07-19 | 2025-07-19 |  | 0d |  | finish on 2025-07-19 |  |
| A1630 |  | Fin de Obras_ Muros Reforzados Paquete 4 | milestone | 0d | 2025-07-30 | 2025-07-30 |  | 0d | 0.28d | finish on 2025-07-30 |  |
| A1640 |  | Fin de obras | milestone | 0d | 2025-07-30 | 2025-07-30 | A2640, A1630, A2710, A130 FF, A2610 FF, A760 FF, A590 FF, A2470 FF, A2940 FF, A1380 FF, A2760 FF, A2750 FF, A2820 FF, A2900 FF, A2430 FF, A1320 FF | -0.28d | 0d | finish on 2025-07-30 |  |
|  | 9 | **TOPOGRAFIA** |  |  | 2024-03-22 | 2025-07-19 |  |  |  |  |  |
| A120 |  | Trazo y replanteo inicial |  | 45d | 2024-03-22 | 2024-05-13 | A1550 | 8.22d | 0d |  | 272.44 |
| A130 |  | Trazo y replanteo durante la obra |  | 410d | 2024-03-29 | 2025-07-19 | A120 SS+6d | 8.22d | 8.5d |  | 272.44 |
|  | 4 | **INSTALACIÓN DE PLANTA DE CONCRETO** |  |  | 2024-03-22 | 2024-04-09 |  |  |  |  |  |
| A2670 |  | Instalación de Planta de Concreto |  | 16d | 2024-03-22 | 2024-04-09 | A1550 | 82.72d | 27d |  |  |
|  | 10 | **PAQUETE 4** |  |  | 2024-03-01 | 2024-12-27 |  |  |  |  |  |
| A2690 |  | Entrega de Terreno Liberado |  | 0d | 2024-03-01 | 2024-03-01 | A1540 SF | -0.28d | 0d |  |  |
| A2700 |  | Inicio de obras Paquete 4 |  | 0d | 2024-03-26 | 2024-03-26 | A2690 FS+21d | 15.72d | 16d |  |  |
| A2710 |  | Fin Paquete 4 | milestone | 0d | 2024-06-25 | 2024-06-25 | A880 | 342.22d | 342.5d |  |  |
|  | 3 | **OBRA PROVISIONAL** |  |  | 2024-03-01 | 2024-04-11 |  |  |  |  |  |
| A1830 |  | Movilizaciones Preliminares |  | 15d | 2024-03-01 | 2024-03-18 | A2690 | -0.28d | 0d |  | 1,000 |
| A1780 |  | Obras Preliminares |  | 21d | 2024-03-19 | 2024-04-11 | A1830 | -0.28d | 0d |  | 272.44 |
| A2030 |  | Habilitacion de zona de trabajo |  | 21d | 2024-03-19 | 2024-04-11 | A1830 | -0.28d | 0d |  | 272.44 |

Notes:
- A120: Expenses: Trazo y replanteo inicial - (cost) 272.44
- A130: Expenses: Trazo y replanteo durante la obra - (cost) 272.44
- A1830: Expenses: Campamento Provisional de Obra - (cost) 1000
- A1780: Expenses: Movilización Y Desmovilización de Maquinaria Pesada - (cost) 272.44
- A2030: Expenses: Eliminación D> 1km Roca (hacia Maní) - (cost) 272.44

| ID | WBS | Activity | Type | Duration | Start | Finish | Predecessors | Total float | Free float | Resources | Cost |
| --- | --- | --- | --- | --- | --- | --- | --- | --- | --- | --- | --- |
|  | 2 | **DIQUES - PAQUETE 4** |  |  | 2024-04-12 | 2024-06-26 |  |  |  |  |  |
|  | 6 | **Retiro de Interferencias** |  |  | 2024-04-12 | 2024-06-25 |  |  |  |  |  |
| A1650 |  | Retiro de Interferencias para Diques del PQT 4 |  | 64d | 2024-04-12 | 2024-06-25 | A2030, A1780 | -0.28d | 0d |  |  |
|  | 1 | **Excavaciones** |  |  | 2024-04-13 | 2024-06-14 |  |  |  |  |  |
| A220 |  | Remoción de dique existente |  | 7d | 2024-04-13 | 2024-04-20 | A240 SS | 351.22d | 0d | EXCAVADORA CAT 336 [63 h]; TRACTOR SOBRE ORUGAS CAT D8T [31.5 h] | 272.44 |
| A230 |  | Desbroce |  | 20d | 2024-04-13 | 2024-05-06 | A1650 SS+1d, A2700 | -0.28d | 0d | EXCAVADORA CAT 336 [90 h]; TRACTOR SOBRE ORUGAS CAT D6D [180 h] | 272.44 |
| A240 |  | Encauzamiento y desvío provisional de río (ataguía) |  | 20d | 2024-04-13 | 2024-05-06 | A230 SS | 351.22d | 0d | EXCAVADORA CAT 336 [45 h]; TRACTOR SOBRE ORUGAS CAT D8T [180 h]; CAMION VOLQUETE 15M3 [180 h] | 272.44 |
| A310 |  | Conformación de material excedente en DME |  | 49d | 2024-04-19 | 2024-06-14 | A410 SS, A220 SS+5d | 351.22d | 0d | EXCAVADORA CAT 336 [264.6 h]; TRACTOR SOBRE ORUGAS CAT D6D [2646 h] | 272.44 |
| A390 |  | Excavación localizada - Sobreexcavación |  | 18d | 2024-04-19 | 2024-05-09 | A410 SS | 382.22d | 31d | EXCAVADORA CAT 336 [324 h] | 272.44 |
| A410 |  | Excavación de cimentación |  | 36d | 2024-04-19 | 2024-05-30 | A230 SS+5d | -0.28d | 0d | EXCAVADORA CAT 336 [1296 h]; TRACTOR SOBRE ORUGAS CAT D8T [648 h]; RETROEXCAVADORA SOBRE LLANTAS 94 HP, 1.25 Y3 [1296 h] | 272.44 |
| A560 |  | Excavación de uña |  | 33d | 2024-05-07 | 2024-06-13 | A230 | 352.22d | 0d | EXCAVADORA CAT 336 [297 h] | 272.44 |
| A750 |  | Conformación de material excedente en DMO |  | 10d | 2024-06-03 | 2024-06-13 | A410 SS, A560 FF | 352.22d | 1d | EXCAVADORA CAT 336 [45 h]; TRACTOR SOBRE ORUGAS CAT D6D [450 h] | 272.44 |
| A760 |  | Fin de Excaciones | milestone | 0d | 2024-06-14 | 2024-06-14 | A310, A750, A390 | 351.22d | 351.5d |  |  |
|  | 2 | **Rellenos** |  |  | 2024-04-25 | 2024-06-07 |  |  |  |  |  |
| A570 |  | Inicio de Rellenos |  | 0d | 2024-04-25 | 2024-04-25 | A410 SS+5d | -0.28d | 0d |  |  |
| A520 |  | Relleno con material seleccionado (incluye extracción de material, zarandeo y combinación de material) en Sobreexcavació |  | 28d | 2024-04-26 | 2024-05-28 | A570 FS+1d | -0.28d | 0d | EXCAVADORA CAT 336 [1008 h]; RODILLO LISO VIBRATORIO MANUAL 10.8 HP 0.8 -1.1 Ton [1008 h] | 272.44 |
| A400 |  | Relleno con material granular (incluye extracción de material, zarandeo y combinación de material) |  | 30d | 2024-05-01 | 2024-06-04 | A410 SS+10d | 22.22d | 0d | TRACTOR SOBRE ORUGAS CAT D6D [810 h]; RETROEXCAVADORA SOBRE LLANTAS 58 HP, 1 Y3 [540 h]; RODILLO LISO VIBRATORIO AUTOPROPULSADO 101-135 HP 10-12TON [1080 h] | 272.44 |
| A540 |  | Relleno sin compactar |  | 2d | 2024-05-02 | 2024-05-03 | A400 SS+1d | 383.22d | 0d | TRACTOR SOBRE ORUGAS CAT D6D [18 h] | 272.44 |
| A580 |  | Relleno afirmado |  | 4d | 2024-05-04 | 2024-05-08 | A540 | 383.22d | 26d | MOTONIVELADORA 140K [36 h]; RODILLO LISO VIBRATORIO AUTOPROPULSADO 101-135 HP 10-12TON [36 h] | 272.44 |
| A620 |  | Perfilado de talud de dique |  | 14d | 2024-05-13 | 2024-05-28 | A520 FF | -0.28d | 0d | EXCAVADORA CAT 336 [378 h] | 272.44 |
| A770 |  | Relleno Material Propio compactado |  | 8d | 2024-05-30 | 2024-06-07 | A400 FF+3d | 357.22d | 0d | RETROEXCAVADORA SOBRE LLANTAS 58 HP, 1 Y3 [180 h]; RODILLO LISO VIBRATORIO MANUAL 10.8 HP 0.8 -1.1 Ton [360 h] | 272.44 |
| A590 |  | Fin de Rellenos | milestone | 0d | 2024-06-07 | 2024-06-07 | A770, A620, A580 | 357.22d | 357.5d |  |  |
|  | 3 | **Geotextil** |  |  | 2024-05-13 | 2024-06-12 |  |  |  |  |  |
| A700 |  | Instalación de Geotextil 400 gr/m2 |  | 25d | 2024-05-13 | 2024-06-10 | A620 SS | -0.28d | 0d | CAMION GRUA 20 TON [450 h] | 272.44 |
| A710 |  | Zanja de anclaje |  | 27d | 2024-05-13 | 2024-06-12 | A700 SS | 55.22d | 0d | RETROEXCAVADORA SOBRE LLANTAS 58 HP, 1 Y3 [486 h]; RODILLO LISO VIBRATORIO MANUAL 10.8 HP 0.8 -1.1 Ton [486 h] | 272.44 |

Notes:
- A220: Expenses: Remoción de dique existente - (cost) 272.44
- A230: Expenses: Desbroce - (cost) 272.44
- A240: Expenses: Encauzamiento y desvío provisional de río (ataguía) - (cost) 272.44
- A310: Expenses: Conformación de material excedente en DME - (cost) 272.44
- A390: Expenses: Excavación localizada - Sobreexcavación - (cost) 272.44
- A410: Expenses: Excavación de cimentación - (cost) 272.44
- A560: Expenses: Excavación de uña - (cost) 272.44
- A750: Expenses: Conformación de material excedente en DMO - (cost) 272.44
- A520: Expenses: Relleno con material seleccionado (incluye extracción de material, zarandeo y combinación de material) en Sobreexcavació 272.44
- A400: Expenses: Relleno con material granular (incluye extracción de material, zarandeo y combinación de material) - (cost) 272.44
- A540: Expenses: Relleno sin compactar - (cost) 272.44
- A580: Expenses: Relleno afirmado - (cost) 272.44
- A620: Expenses: Perfilado de Talud del dique - (cost) 272.44
- A770: Expenses: Relleno Material Propio compactado - (cost) 272.44
- A700: Expenses: Instalación de Geotextil 400 gr/m2 - (cost) 272.44
- A710: Expenses: Zanja de anclaje - (cost) 272.44

| ID | WBS | Activity | Type | Duration | Start | Finish | Predecessors | Total float | Free float | Resources | Cost |
| --- | --- | --- | --- | --- | --- | --- | --- | --- | --- | --- | --- |
|  | 4 | **Colocación de roca** |  |  | 2024-05-13 | 2024-06-26 |  |  |  |  |  |
| A630 |  | Enrocado cauce de rio |  | 25d | 2024-05-13 | 2024-06-10 | A640 SS | -0.28d | 0d | EXCAVADORA CAT 336 [2250 h]; TRACTOR SOBRE ORUGAS CAT D6D [562.5 h] | 272.44 |
| A640 |  | Colocación de roca en uña |  | 35d | 2024-05-13 | 2024-06-21 | A700 SS | -0.28d | 0d | EXCAVADORA CAT 336 [1260 h]; TRACTOR SOBRE ORUGAS CAT D6D [126 h] | 272.44 |
| A650 |  | Colocación de roca en Talud |  | 38d | 2024-05-13 | 2024-06-25 | A640 SS | 6.72d | 0d | EXCAVADORA CAT 336 [1368 h]; TRACTOR SOBRE ORUGAS CAT D6D [68.4 h] | 272.44 |
| A840 |  | Extracción y selección de Rocas Reutilizables |  | 21d | 2024-06-01 | 2024-06-25 | A650 FF | 6.72d | 7d | EXCAVADORA CAT 336 [378 h] | 272.44 |
| A850 |  | Concreto f'c=210kg/cm2 para Recebado |  | 12d | 2024-06-13 | 2024-06-26 | A630 FS+2d, A840 SS+3d, A2670 SF | -0.28d | 0d | CAMION MIXER [324 h]; CARGADOR FRONTAL CAT-966-H [324 h] | 272.44 |
| A860 |  | Protección de Talud con Colchón Reno 6m largo x e= 0.30cm |  | 6d | 2024-06-20 | 2024-06-26 | A650 FF+1d | 341.22d | 0d | RETROEXCAVADORA SOBRE LLANTAS 94 HP, 1.25 Y3 [27 h] | 272.44 |
| A870 |  | Malla Gavión de 1m x 1m x 5m |  | 5d | 2024-06-20 | 2024-06-25 | A860 SS | 342.22d | 0d | RETROEXCAVADORA SOBRE LLANTAS 94 HP, 1.25 Y3 [22.5 h] | 272.44 |
| A880 |  | Fin de Colocacion de roca | milestone | 0d | 2024-06-25 | 2024-06-25 | A870, A860 SF | 342.22d | 0d |  |  |
|  | 5 | **Transportes** |  |  | 2024-04-19 | 2024-06-25 |  |  |  |  |  |
| A320 |  | Transporte de material orgánico (a DMO) D<=1km |  | 41d | 2024-04-19 | 2024-06-05 | A410 SS | 38.22d | 0d |  | 272.44 |
| A330 |  | Transporte de material orgánico (a DMO) D>1km |  | 41d | 2024-04-19 | 2024-06-05 | A320 SS | 38.22d | 17d | CAMION VOLQUETE 15M3 [2296 h] | 272.44 |
| A340 |  | Transporte de material excedente D<= 1km |  | 57d | 2024-04-20 | 2024-06-25 | A410 SS+1d | 21.22d | 0d |  | 272.44 |
| A350 |  | Transporte de material excedente D> 1km |  | 57d | 2024-04-20 | 2024-06-25 | A340 SS | 21.22d | 0d | CAMION VOLQUETE 15M3 [7695 h]; CAMION VOLQUETE 22M3 [7695 h] | 272.44 |
| A360 |  | Transporte de material de préstamo cantera de rio (cuerpo de terraplén) D<=1km |  | 42d | 2024-05-01 | 2024-06-18 | A400 SS | 27.22d | 0d |  | 272.44 |
| A370 |  | Transporte de material de préstamo cantera de rio (cuerpo de terraplén) D>1km |  | 42d | 2024-05-01 | 2024-06-18 | A360 SS | 27.22d | 6d | CAMION VOLQUETE 22M3 [3024 h] | 272.44 |
| A500 |  | Transporte de material de préstamo (afirmado) D<= 1km |  | 45d | 2024-05-03 | 2024-06-24 | A400 SS+2d | 22.22d | 0d |  | 272.44 |
| A510 |  | Transporte de material de préstamo (afirmado) D> 1km |  | 45d | 2024-05-03 | 2024-06-24 | A500 SS | 22.22d | 1d | CAMION VOLQUETE 22M3 [8910 h] | 272.44 |
| A660 |  | Transporte de roca D<=1km |  | 38d | 2024-05-13 | 2024-06-25 | A700 FF, A650 FF | 21.22d | 0d |  | 272.44 |
| A670 |  | Transporte de roca D>1km |  | 38d | 2024-05-13 | 2024-06-25 | A660 SS | 21.22d | 0d | CAMION VOLQUETE 22M3 [2394 h] | 272.44 |
| A680 |  | Transporte de material seleccionado para zanja D> 1km |  | 4d | 2024-05-13 | 2024-05-16 | A690 SS | 55.22d | 34d | CAMION VOLQUETE 15M3 [252 h] | 272.44 |
| A690 |  | Transporte de material seleccionado para zanja D<= 1km |  | 4d | 2024-05-13 | 2024-05-16 | A710 SS | 55.22d | 0d |  | 272.44 |
| A720 |  | Fin de Transporte | milestone | 0d | 2024-06-25 | 2024-06-25 | A350, A330, A370, A510, A670, A680 | 21.22d | 5d |  |  |
|  | 1 | **MUROS PAQUETE 4** |  |  | 2024-03-20 | 2024-12-27 |  |  |  |  |  |
|  | 1 | **Muro Carquin (MT3)** |  |  | 2024-03-20 | 2024-07-10 |  |  |  |  |  |
|  | 2 | **Muro Carquín** |  |  | 2024-03-20 | 2024-07-05 |  |  |  |  |  |
| A460 |  | Encofrado y Desencofrado Caravista |  | 32d | 2024-03-20 | 2024-04-25 | A450 FF+3d | 107.22d | 31d | CAMION GRUA 20 TON [288 h] | 272.44 |
| A450 |  | Concreto de Nivelacion (f'c=100 kg/cm2) |  | 9d | 2024-04-12 | 2024-04-22 | A1570, A2670 SF, A2690, A1650 SS | 84.22d | 0d | CAMION MIXER [81 h]; CARGADOR FRONTAL CAT-966-H [81 h] | 272.44 |
| A300 |  | Acero de refuerzo f'y=4200kg/cm2 |  | 49d | 2024-04-16 | 2024-06-11 | A450 SS+3d | 84.22d | 8d |  | 272.44 |
| A210 |  | Encofrado y Desencofrado Cara Oculta |  | 46d | 2024-04-25 | 2024-06-17 | A410 SS+5d | 76.22d | 0d | CAMION GRUA 20 TON [414 h] | 272.44 |
| A530 |  | Concreto Clase C (f'c=280 kg/cm2) Premezclado - Cimientos reforzados |  | 45d | 2024-04-29 | 2024-06-19 | A300 SS+3d, A210 SS+3d, A460 SS+3d, A2670 SF | 76.22d | 0d | CAMION MIXER [405 h]; CARGADOR FRONTAL CAT-966-H [405 h] | 272.44 |
| A610 |  | Concreto Clase C (f'c=280 kg/cm2) Premezclado - Muros de contención |  | 45d | 2024-05-07 | 2024-06-27 | A530 SS+7d, A2670 SF | 76.22d | 0d | CARGADOR FRONTAL CAT-966-H [405 h]; CAMION MIXER [405 h] | 272.44 |
| A730 |  | Pintura Bituminosa |  | 10d | 2024-06-25 | 2024-07-05 | A610 FF+7d | 222.22d | 0d |  | 272.44 |

Notes:
- A630: Expenses: Enrocado cauce de rio - (cost) 272.44
- A640: Expenses: Colocación de roca en uña - (cost) 272.44
- A650: Expenses: Colocación de roca en Talud - (cost) 272.44
- A840: Expenses: Extracción y selección de Rocas Reutilizables - (cost) 272.44
- A850: Expenses: Concreto f'c=210kg/cm2 para Recebado - (cost) 272.44
- A860: Expenses: Protección de Talud con Colchón Reno 6m largo x e= 0.30cm - (cost) 272.44
- A870: Expenses: Malla Gavión de 1m x 1m x 5m - (cost) 272.44
- A320: Expenses: Transporte de material orgánico (a DMO) D<=1km - (cost) 272.44
- A330: Expenses: Transporte de material orgánico (a DMO) D>1km - (cost) 272.44
- A340: Expenses: Transporte de material excedente D<= 1km - (cost) 272.44
- A350: Expenses: Transporte de material excedente D> 1km - (cost) 272.44
- A360: Expenses: Transporte de material de préstamo cantera de rio (cuerpo de terraplén) D<=1km - (cost) 272.44
- A370: Expenses: Transporte de material de préstamo cantera de rio (cuerpo de terraplén) D>1km - (cost) 272.44
- A500: Expenses: Transporte de material de préstamo (afirmado) D<= 1km - (cost) 272.44
- A510: Expenses: Transporte de material de préstamo (afirmado) D> 1km - (cost) 272.44
- A660: Expenses: Transporte de roca D<=1km - (cost) 272.44
- A670: Expenses: Transporte de roca D>1km - (cost) 272.44
- A680: Expenses: Transporte de material seleccionado para zanja D> 1km - (cost) 272.44
- A690: Expenses: Transporte de material seleccionado para zanja D<= 1km - (cost) 272.44
- A460: Expenses: Encofrado y Desencofrado Caravista - (cost) 272.44
- A450: Expenses: Concreto de Nivelacion (f'c=100 kg/cm2) - (cost) 272.44
- A300: Expenses: Acero de refuerzo f'y=4200kg/cm2 - (cost) 272.44
- A210: Expenses: Encofrado y Desencofrado Cara Oculta - (cost) 272.44
- A530: Expenses: Concreto Clase C (f'c=280 kg/cm2) Premezclado - Cimientos reforzados - (cost) 272.44
- A610: Expenses: Concreto Clase C (f'c=280 kg/cm2) Premezclado - Muros de contención - (cost) 272.44
- A730: Expenses: Pintura Bituminosa - (cost) 272.44

| ID | WBS | Activity | Type | Duration | Start | Finish | Predecessors | Total float | Free float | Resources | Cost |
| --- | --- | --- | --- | --- | --- | --- | --- | --- | --- | --- | --- |
|  | 1 | **Relleno** |  |  | 2024-06-07 | 2024-07-10 |  |  |  |  |  |
| A2500 |  | Relleno Material Propio compactado |  | 27d | 2024-06-07 | 2024-07-08 | A730 FF+2d | 222.22d | 146d | EXCAVADORA CAT 336 [243 h]; RODILLO LISO VIBRATORIO AUTOPROPULSADO 101-135 HP 10-12TON [243 h] | 272.44 |
| A2460 |  | Relleno con material seleccionado (incluye extracción de material, zarandeo y combinación de material) en Sobreexcavació |  | 15d | 2024-06-22 | 2024-07-09 | A730 FF+3d | 330.22d | 0d | RETROEXCAVADORA SOBRE LLANTAS 58 HP, 1 Y3 [67.5 h]; RODILLO LISO VIBRATORIO MANUAL 10.8 HP 0.8 -1.1 Ton [135 h] | 272.44 |
| A2470 |  | Fin de Muro Carquín (MT3) |  | 0d | 2024-07-10 | 2024-07-10 | A2460 | 330.22d | 330.5d |  |  |
|  | 2 | **Muros Sayán (Mt3)** |  |  | 2024-06-28 | 2024-12-27 |  |  |  |  |  |
| A2940 |  | Diques Provisionales |  | 155d | 2024-06-28 | 2024-12-25 | A2610 FF | 185.22d | 185.5d |  |  |
|  | 2 | **Muro Sayán** |  |  | 2024-06-28 | 2024-12-27 |  |  |  |  |  |
| A820 |  | Demolición de Obras |  | 25d | 2024-06-28 | 2024-07-26 | A610, A210 SS+3d | 76.22d | 0d | EXCAVADORA CAT 336 [225 h]; MARTILLO HIDRAULICO P/EXCAVADORA [225 h] | 272.44 |
| A740 |  | Concreto de Nivelacion (f'c=100 kg/cm2) |  | 50d | 2024-07-03 | 2024-08-29 | A610, A820 SS+4d, A2670 SF | 76.22d | 0d | CAMION MIXER [450 h]; CARGADOR FRONTAL CAT-966-H [450 h] | 272.44 |
| A790 |  | Encofrado y Desencofrado Caravista |  | 120d | 2024-07-10 | 2024-11-26 | A740 SS+6d, A210 SS+5d | 76.22d | 0d | CAMION GRUA 20 TON [4320 h] | 272.44 |
| A810 |  | Acero de refuerzo f'y=4200kg/cm2 |  | 98d | 2024-07-10 | 2024-10-31 | A790 SS | 183.22d | 0d |  | 272.44 |
| A800 |  | Encofrado y Desencofrado Cara Oculta |  | 120d | 2024-07-13 | 2024-11-29 | A790 FF+3d | 78.22d | 2d | CAMION GRUA 20 TON [1944 h] | 272.44 |
| A780 |  | Concreto Clase C (f'c=280 kg/cm2) Premezclado - Cimientos reforzados |  | 120d | 2024-07-16 | 2024-12-02 | A790 SS+5d, A2670 SF, A210 SS+5d, A800 SS | 76.22d | 0d | CAMION MIXER [2160 h]; CARGADOR FRONTAL CAT-966-H [2160 h] | 272.44 |
| A1060 |  | Acero para anclajes |  | 46d | 2024-07-22 | 2024-09-12 | A810 SS+10d | 183.22d | 0d |  | 272.44 |
| A940 |  | Concreto Clase C (f'c=280 kg/cm2) Premezclado - Muros de contención |  | 120d | 2024-07-23 | 2024-12-09 | A780 SS+6d, A2670 SF | 76.22d | 0d | CARGADOR FRONTAL CAT-966-H [2160 h]; CAMION MIXER [2160 h] | 272.44 |
| A1320 |  | Junta de dilatación |  | 120d | 2024-07-29 | 2024-12-14 | A940 SS+5d | 194.22d | 194.5d |  | 272.44 |
| A1270 |  | SHOTCRETE (f'c= 210 kg/cm2) |  | 25d | 2024-08-02 | 2024-08-30 | A1060 SS+2d, A1280 SS | 183.22d | 0d | SHOTCRETERA [225 h] | 272.44 |
| A1280 |  | PERNOS DE ANCLAJE D=30mm SOIL NAILING (TIPO TITAN 30/11) Fu=320kN |  | 25d | 2024-08-02 | 2024-08-30 | A1060 SS+10d | 183.22d | 0d |  | 272.44 |
| A1260 |  | MALLA ELECTROSOLDADA (TIPO ACMA C503) |  | 25d | 2024-08-08 | 2024-09-05 | A1270 SS+5d | 183.22d | 0d |  | 272.44 |
| A1290 |  | Concreto Clase C (f'c=280 kg/cm2) Premezclado - Muros de anclaje |  | 75d | 2024-08-31 | 2024-11-26 | A2670 SF, A1260 SS+20d, A1280 | 183.22d | 0d | CAMION MIXER [1350 h]; CARGADOR FRONTAL CAT-966-H [1350 h] | 272.44 |
| A1300 |  | Pintura Bituminosa |  | 80d | 2024-09-13 | 2024-12-14 | A940 FF+5d | 76.22d | 0d |  | 272.44 |
| A2920 |  | Tesado de Cables |  | 60d | 2024-10-19 | 2024-12-27 | A1290 FF+27d | 183.22d | 183.5d |  | 272.44 |
|  | 1 | **Relleno** |  |  | 2024-12-03 | 2024-12-25 |  |  |  |  |  |
| A2520 |  | Relleno con material granular (incluye extracción de material, zarandeo y combinación de material) |  | 13d | 2024-12-03 | 2024-12-17 | A1300 FF+2d | 76.22d | 0d | TRACTOR SOBRE ORUGAS CAT D6D [117 h]; RODILLO LISO VIBRATORIO AUTOPROPULSADO 101-135 HP 10-12TON [117 h]; RETROEXCAVADORA SOBRE LLANTAS 58 HP, 1 Y3 [117 h]; TRACTOR SOBRE ORUGAS CAT D6D [58.5 h] | 272.44 |
| A2570 |  | Relleno Material Propio compactado |  | 13d | 2024-12-03 | 2024-12-17 | A2520 FF | 83.22d | 7d | RETROEXCAVADORA SOBRE LLANTAS 58 HP, 1 Y3 [58.5 h] | 272.44 |
| A2530 |  | Relleno con material seleccionado (incluye extracción de material, zarandeo y combinación de material) en Sobreexcavació |  | 18d | 2024-12-05 | 2024-12-25 | A2520 FF+7d, A940 FF+7d | 76.22d | 0d | EXCAVADORA CAT 336 [2268 h]; RODILLO LISO VIBRATORIO AUTOPROPULSADO 101-135 HP 10-12TON [2268 h] | 272.44 |
| A2560 |  | Perfilado de Talud del dique |  | 8d | 2024-12-17 | 2024-12-25 | A2530 FF | 76.22d | 0d | EXCAVADORA CAT 336 [21.6 h] | 272.44 |
| A2610 |  | Fin de Muros Sayán | milestone | 0d | 2024-12-25 | 2024-12-25 | A2560, A2570, A2500 | 76.22d | 0d |  |  |

Notes:
- A2500: Expenses: Relleno Material Propio compactado - (cost) 272.44
- A2460: Expenses: Relleno con material seleccionado (incluye extracción de material, zarandeo y combinación de material) en Sobreexcavació 272.44
- A820: Expenses: Demolición de Obras - (cost) 272.44
- A740: Expenses: Concreto de Nivelacion (f'c=100 kg/cm2) - (cost) 272.44
- A790: Expenses: Encofrado y Desencofrado Caravista - (cost) 272.44
- A810: Expenses: Acero de refuerzo f'y=4200kg/cm2 - (cost) 272.44
- A800: Expenses: Encofrado y Desencofrado Cara Oculta - (cost) 272.44
- A780: Expenses: Concreto Clase C (f'c=280 kg/cm2) Premezclado - Cimientos reforzados - (cost) 272.44
- A1060: Expenses: Acero para anclajes - (cost) 272.44
- A940: Expenses: Concreto Clase C (f'c=280 kg/cm2) Premezclado - Muros de contención - (cost) 272.44
- A1320: Expenses: Junta de dilatación - (cost) 272.44
- A1270: Expenses: SHOTCRETE (f'c= 210 kg/cm2) - (cost) 272.44
- A1280: Expenses: PERNOS DE ANCLAJE D=30mm SOIL NAILING (TIPO TITAN 30/11) Fu=320kN - (cost) 272.44
- A1260: Expenses: MALLA ELECTROSOLDADA (TIPO ACMA C503) - (cost) 272.44
- A1290: Expenses: Concreto Clase C (f'c=280 kg/cm2) Premezclado - Muros de anclaje - (cost) 272.44
- A1300: Expenses: Tesado de Cables - (cost) 272.44
- A2920: Expenses: Tesado de Cables - (cost) 272.44
- A2520: Expenses: Relleno con material granular (incluye extracción de material, zarandeo y combinación de material) - (cost) 272.44
- A2570: Expenses: Relleno Material Propio compactado - (cost) 272.44
- A2530: Expenses: Relleno con material seleccionado (incluye extracción de material, zarandeo y combinación de material) en Sobreexcavació 272.44
- A2560: Expenses: Perfilado de Talud del dique - (cost) 272.44

| ID | WBS | Activity | Type | Duration | Start | Finish | Predecessors | Total float | Free float | Resources | Cost |
| --- | --- | --- | --- | --- | --- | --- | --- | --- | --- | --- | --- |
|  | 7 | **CUENCA ALTA** |  |  | 2024-06-03 | 2025-07-30 |  |  |  |  |  |
| A2720 |  | Entrega de Terreno Liberado |  | 0d | 2024-06-03 | 2024-06-03 | A1540 FS+80d | 187.22d | 0d |  |  |
| A2730 |  | Inicio de obras Cuenca Alta |  | 0d | 2024-06-27 | 2024-06-27 | A1660 SS | 341.22d | 341.5d |  |  |
| A2740 |  | Fin de Obras Cuenca Alta | milestone | 0d | 2025-07-30 | 2025-07-30 | A2790 | -0.28d | 0d |  |  |
|  | 7 | **OBRA PROVISIONAL** |  |  | 2024-06-03 | 2024-12-31 |  |  |  |  |  |
| A2360 |  | Movilizaciones Preliminares |  | 5d | 2024-06-03 | 2024-06-07 | A2720 | 187.22d | 0d |  | 272.44 |
| A2370 |  | Obras Preliminares |  | 15d | 2024-06-08 | 2024-06-25 | A2360 | 187.22d | 0d |  | 272.44 |
| A2380 |  | Habilitacion de zona de trabajo |  | 15d | 2024-06-08 | 2024-06-25 | A2360, A2370 SS | 187.22d | 1d |  | 272.44 |
| A2450 |  | Desmovilizacion de Equipos parcial |  | 5d | 2024-12-26 | 2024-12-31 | A2610 | 76.22d | 76.5d |  |  |
|  | 13 | **DIQUES CUENTA ALTA** |  |  | 2024-06-27 | 2024-12-24 |  |  |  |  |  |
|  | 6 | **Retiro de Interferencias** |  |  | 2024-06-27 | 2024-12-24 |  |  |  |  |  |
| A1660 |  | Retiro de Interferencias para Cuenca Alta |  | 155d | 2024-06-27 | 2024-12-24 | A1600, A2380 | 186.22d | 0d |  |  |
|  | 1 | **Excavaciones** |  |  | 2024-06-28 | 2024-10-23 |  |  |  |  |  |
| A930 |  | Desbroce |  | 18d | 2024-06-28 | 2024-07-18 | A850 SS+13d, A1600 | -0.28d | 0d | EXCAVADORA CAT 336 [162 h]; TRACTOR SOBRE ORUGAS CAT D6D [324 h] | 272.44 |
| A1010 |  | Excavación de cimentación |  | 65d | 2024-07-02 | 2024-09-14 | A930 SS+3d | -0.28d | 0d | TRACTOR SOBRE ORUGAS CAT D8T [877.5 h]; EXCAVADORA CAT 336 [1755 h] | 272.44 |
| A1040 |  | Perfilado y conformación de Plataforma de fundación |  | 50d | 2024-07-23 | 2024-09-18 | A1010 FF+3d | 240.22d | 0d | MOTONIVELADORA 140K [900 h]; RODILLO LISO VIBRATORIO AUTOPROPULSADO 101-135 HP 10-12TON [900 h]; CAMION CISTERNA [900 h] | 272.44 |
| A1190 |  | Excavación de uña |  | 54d | 2024-07-31 | 2024-10-01 | A1040 FF+11d | 240.22d | 0d | EXCAVADORA CAT 336 [972 h] | 272.44 |
| A1220 |  | Conformación de material excedente en DMO |  | 70d | 2024-08-02 | 2024-10-22 | A1180 FF | 240.22d | 0d | TRACTOR SOBRE ORUGAS CAT D6D [630 h]; EXCAVADORA CAT 336 [63 h] | 272.44 |
| A1180 |  | Conformación de material excedente en DME |  | 63d | 2024-08-10 | 2024-10-22 | A1190 SS+9d | 240.22d | 0d | EXCAVADORA CAT 336 [396.9 h]; TRACTOR SOBRE ORUGAS CAT D6D [3969 h] | 272.44 |
| A1370 |  | Excavación localizada - Sobreexcavación |  | 7d | 2024-10-02 | 2024-10-09 | A1010, A1190 | 251.22d | 11d | EXCAVADORA CAT 336 [63 h] | 272.44 |
| A1380 |  | Fin de Excavaciones |  | 0d | 2024-10-23 | 2024-10-23 | A1220, A1370 | 240.22d | 240.5d |  |  |
|  | 2 | **Rellenos** |  |  | 2024-07-09 | 2024-11-07 |  |  |  |  |  |
| A1050 |  | Relleno con material granular (incluye extracción de material, zarandeo y combinación de material) |  | 65d | 2024-07-09 | 2024-09-21 | A1010 FF+6d | -0.28d | 0d | TRACTOR SOBRE ORUGAS CAT D6D [1462.5 h]; RODILLO LISO VIBRATORIO AUTOPROPULSADO 101-135 HP 10-12TON [1462.5 h]; RETROEXCAVADORA SOBRE LLANTAS 58 HP, 1 Y3 [1170 h] | 272.44 |
| A1070 |  | Perfilado de Talud del dique |  | 58d | 2024-07-17 | 2024-09-21 | A1050 FF | -0.28d | 0d | EXCAVADORA CAT 336 [156.6 h] | 272.44 |
| A1130 |  | Relleno con material seleccionado (incluye extracción de material, zarandeo y combinación de material) en Sobreexcavació |  | 44d | 2024-07-19 | 2024-09-07 | A1050 SS+9d | 19.22d | 0d | EXCAVADORA CAT 336 [396 h]; RODILLO LISO VIBRATORIO AUTOPROPULSADO 101-135 HP 10-12TON [396 h] | 272.44 |
| A1330 |  | Grava para drenaje |  | 4d | 2024-09-09 | 2024-09-12 | A1130 | 226.22d | 0d | RETROEXCAVADORA SOBRE LLANTAS 94 HP, 1.25 Y3 [36 h] | 272.44 |
| A1340 |  | Relleno Material Propio compactado |  | 35d | 2024-09-09 | 2024-10-18 | A1330 SS | 226.22d | 0d | RETROEXCAVADORA SOBRE LLANTAS 58 HP, 1 Y3 [157.5 h]; RODILLO LISO VIBRATORIO MANUAL 10.8 HP 0.8 -1.1 Ton [315 h] | 272.44 |
| A1360 |  | Relleno sin compactar |  | 10d | 2024-09-23 | 2024-10-03 | A1050 | 256.22d | 30d | TRACTOR SOBRE ORUGAS CAT D6D [90 h] | 272.44 |
| A1350 |  | Relleno afirmado |  | 17d | 2024-10-19 | 2024-11-07 | A1360 FF, A1340 | 226.22d | 0d | RODILLO LISO VIBRATORIO AUTOPROPULSADO 101-135 HP 10-12TON [918 h]; MOTONIVELADORA 140K [918 h] | 272.44 |
| A2760 |  | Fin de Rellenos | milestone | 0d | 2024-11-07 | 2024-11-07 | A1350 | 226.22d | 226.5d |  |  |

Notes:
- A2360: Expenses: Campamento Provisional de Obra - (cost) 272.44
- A2370: Expenses: Movilización Y Desmovilización de Maquinaria Pesada - (cost) 272.44
- A2380: Expenses: Eliminación D> 1km Roca (hacia Maní) - (cost) 272.44
- A930: Expenses: Desbroce - (cost) 272.44
- A1010: Expenses: Excavación de cimentación - (cost) 272.44
- A1040: Expenses: Perfilado y conformación de Plataforma de fundación - (cost) 272.44
- A1190: Expenses: Excavación de uña - (cost) 272.44
- A1220: Expenses: Conformación de material excedente en DMO - (cost) 272.44
- A1180: Expenses: Conformación de material excedente en DME - (cost) 272.44
- A1370: Expenses: Excavación localizada - Sobreexcavación - (cost) 272.44
- A1050: Expenses: Relleno con material granular (incluye extracción de material, zarandeo y combinación de material) - (cost) 272.44
- A1070: Expenses: Perfilado de Talud del dique - (cost) 272.44
- A1130: Expenses: Relleno con material seleccionado (incluye extracción de material, zarandeo y combinación de material) en Sobreexcavació 272.44
- A1330: Expenses: Grava para drenaje - (cost) 272.44
- A1340: Expenses: Relleno Material Propio compactado - (cost) 272.44
- A1360: Expenses: Relleno sin compactar - (cost) 272.44
- A1350: Expenses: Relleno afirmado - (cost) 272.44

| ID | WBS | Activity | Type | Duration | Start | Finish | Predecessors | Total float | Free float | Resources | Cost |
| --- | --- | --- | --- | --- | --- | --- | --- | --- | --- | --- | --- |
|  | 3 | **Geotextil** |  |  | 2024-07-17 | 2024-11-16 |  |  |  |  |  |
| A1080 |  | Instalación de Geotextil 400 gr/m2 |  | 106d | 2024-07-17 | 2024-11-16 | A1070 SS | -0.28d | 0d | CAMION GRUA 20 TON [1144.8 h] | 272.44 |
| A1090 |  | Zanja de anclaje |  | 52d | 2024-07-17 | 2024-09-14 | A1080 SS | 2.72d | 0d | RETROEXCAVADORA SOBRE LLANTAS 58 HP, 1 Y3 [468 h]; RODILLO LISO VIBRATORIO MANUAL 10.8 HP 0.8 -1.1 Ton [468 h] | 272.44 |
|  | 4 | **Colocación de roca** |  |  | 2024-07-20 | 2024-12-16 |  |  |  |  |  |
| A1120 |  | Colocación de roca en uña |  | 106d | 2024-07-20 | 2024-11-20 | A1080 SS+3d, A1090 SS | -0.28d | 0d | TRACTOR SOBRE ORUGAS CAT D6D [381.6 h]; EXCAVADORA CAT 336 [3816 h] | 272.44 |
| A1240 |  | Colocación de roca en Talud |  | 115d | 2024-08-05 | 2024-12-16 | A1120 SS+13d | -0.28d | 0d | EXCAVADORA CAT 336 [6210 h]; TRACTOR SOBRE ORUGAS CAT D6D [621 h] | 272.44 |
|  | 5 | **Transportes** |  |  | 2024-07-02 | 2024-12-16 |  |  |  |  |  |
| A1000 |  | Transporte de material excedente D> 1km |  | 127d | 2024-07-02 | 2024-11-26 | A990 SS, A720 | 16.22d | 16.5d |  | 272.44 |
| A970 |  | Transporte de material orgánico (a DMO) D<=1km |  | 101d | 2024-07-02 | 2024-10-26 | A1010 SS | 42.22d | 0d | CAMION VOLQUETE 15M3 [11817 h] | 272.44 |
| A980 |  | Transporte de material orgánico (a DMO) D>1km |  | 101d | 2024-07-02 | 2024-10-26 | A970 SS | 42.22d | 42.5d |  | 272.44 |
| A990 |  | Transporte de material excedente D<= 1km |  | 127d | 2024-07-02 | 2024-11-26 | A1010 SS | 16.22d | 0d | CAMION VOLQUETE 22M3 [32004 h]; CAMION VOLQUETE 15M3 [32004 h] | 272.44 |
| A1100 |  | Transporte de material seleccionado para zanja D<= 1km |  | 10d | 2024-07-17 | 2024-07-27 | A1090 SS | 120.22d | 0d | CAMION VOLQUETE 15M3 [1350 h] | 272.44 |
| A1110 |  | Transporte de material seleccionado para zanja D> 1km |  | 10d | 2024-07-17 | 2024-07-27 | A1100 SS | 120.22d | 120.5d |  | 272.44 |
| A1140 |  | Transporte de material de prestamo (afirmado) D<= 1km |  | 60d | 2024-07-19 | 2024-09-26 | A1130 SS | 68.22d | 0d | CAMION VOLQUETE 22M3 [11880 h] | 272.44 |
| A1150 |  | Transporte de material de prestamo (afirmado) D> 1km |  | 60d | 2024-07-19 | 2024-09-26 | A1140 SS | 68.22d | 68.5d |  | 272.44 |
| A1160 |  | Transporte de material de préstamo cantera de rio (cuerpo de terraplén) D<=1km |  | 109d | 2024-07-19 | 2024-11-22 | A1130 SS | 19.22d | 0d | CAMION VOLQUETE 22M3 [17658 h] | 272.44 |
| A1170 |  | Transporte de material de préstamo cantera de rio (cuerpo de terraplén) D>1km |  | 109d | 2024-07-19 | 2024-11-22 | A1160 SS | 19.22d | 19.5d |  | 272.44 |
| A1200 |  | Transporte de roca D<=1km |  | 120.5d | 2024-07-29 | 2024-12-16 | A1240 FF | -0.28d | 0d |  | 272.44 |
| A1210 |  | Transporte de roca D>1km |  | 120d | 2024-07-29 | 2024-12-16 | A1200 SS | -0.28d | 0d | CAMION VOLQUETE 22M3 [16200 h] | 272.44 |
| A2770 |  | Fin de Excavaciones | milestone | 0d | 2024-12-16 | 2024-12-16 | A1210, A980, A1000, A1110, A1150, A1170 | -0.28d | 0d |  |  |
|  | 12 | **MUROS CUENCA ALTA** |  |  | 2024-12-16 | 2025-07-30 |  |  |  |  |  |
| A2910 |  | Paralización por crecida de Rio |  | 90d | 2024-12-16 | 2025-03-31 | A2770 | -0.28d | 0d |  |  |
| A2930 |  | Movilizacion de Equipos para reinicio de actividades |  | 14d | 2025-03-31 | 2025-04-16 | A2910, A2450 | -0.28d | 0d |  |  |
|  | 2 | **Muro Cuenca Alta** |  |  | 2025-04-16 | 2025-07-30 |  |  |  |  |  |
| A1390 |  | Concreto de Nivelacion (f'c=100 kg/cm2) |  | 23d | 2025-04-16 | 2025-05-13 | A1240 FF+111d, A1570, A2670 SF, A2930 | -0.28d | 0d | CAMION MIXER [207 h]; CARGADOR FRONTAL CAT-966-H [207 h] | 272.44 |
| A1400 |  | Concreto Ciclópeo (f'c=280 kg/cm2) + 30%PG. |  | 50d | 2025-04-23 | 2025-06-20 | A1390 SS+6d, A2670 SF | -0.28d | 0d | RETROEXCAVADORA SOBRE LLANTAS 94 HP, 1.25 Y3 [1800 h]; CARGADOR FRONTAL CAT-966-H [1800 h] | 272.44 |
| A1410 |  | Encofrado y Desencofrado Caravista |  | 37d | 2025-04-26 | 2025-06-09 | A1390 SS+9d | 8.72d | 0d | CAMION GRUA 20 TON [1332 h] | 272.44 |
| A1420 |  | Encofrado y Desencofrado Cara Oculta |  | 50d | 2025-04-26 | 2025-06-24 | A1410 SS | 9.72d | 10d | CAMION GRUA 20 TON [450 h] | 272.44 |
| A1430 |  | Acero de refuerzo f'y=4200kg/cm2 |  | 45d | 2025-04-26 | 2025-06-18 | A1410 SS | 8.72d | 9d |  | 272.44 |
| A1440 |  | Concreto Clase C (f'c=280 kg/cm2) Premezclado - Cimientos reforzados |  | 50d | 2025-05-10 | 2025-07-08 | A1400 SS+15d, A2670 SF, A1420 SS+2d, A1430 SS+3d | -0.28d | 0d | CAMION MIXER [675 h]; CARGADOR FRONTAL CAT-966-H [675 h] | 272.44 |
| A1450 |  | Concreto Clase C (f'c=280 kg/cm2) Premezclado - Muros de contención |  | 50d | 2025-05-29 | 2025-07-26 | A1440 SS+16d, A2670 SF | -0.28d | 0d | CARGADOR FRONTAL CAT-966-H [450 h]; CAMION MIXER [450 h] | 272.44 |
| A1460 |  | Pintura Bituminosa |  | 39d | 2025-06-14 | 2025-07-30 | A1450 SS+6d, A1450 FF+3d | -0.28d | 0d |  | 272.44 |
| A1470 |  | Tubo PVC - D=6'' |  | 12d | 2025-06-24 | 2025-07-08 | A1480 FF | 18.72d | 0d |  | 272.44 |
| A1480 |  | Geocompuesto de Drenaje |  | 4d | 2025-07-03 | 2025-07-08 | A1440 FF | 18.72d | 0d |  | 272.44 |
| A1490 |  | Tubo PVC - D=4'' |  | 3d | 2025-07-04 | 2025-07-08 | A1470 FF | 18.72d | 19d |  | 272.44 |
| A2790 |  | Fin de muro Cuenca Alta | milestone | 0d | 2025-07-30 | 2025-07-30 | A1460, A1490 FF | -0.28d | 0d |  |  |

Notes:
- A1080: Expenses: Instalación de Geotextil 400 gr/m2 - (cost) 272.44
- A1090: Expenses: Zanja de anclaje - (cost) 272.44
- A1120: Expenses: Colocación de roca en uña - (cost) 272.44
- A1240: Expenses: Colocación de roca en Talud - (cost) 272.44
- A1000: Expenses: Transporte de material excedente D> 1km - (cost) 272.44
- A970: Expenses: Transporte de material orgánico (a DMO) D<=1km - (cost) 272.44
- A980: Expenses: Transporte de material orgánico (a DMO) D>1km - (cost) 272.44
- A990: Expenses: Transporte de material excedente D<= 1km - (cost) 272.44
- A1100: Expenses: Transporte de material seleccionado para zanja D<= 1km - (cost) 272.44
- A1110: Expenses: Transporte de material seleccionado para zanja D> 1km - (cost) 272.44
- A1140: Expenses: Transporte de material de prestamo (afirmado) D<= 1km - (cost) 272.44
- A1150: Expenses: Transporte de material de prestamo (afirmado) D> 1km - (cost) 272.44
- A1160: Expenses: Transporte de material de préstamo cantera de rio (cuerpo de terraplén) D<=1km - (cost) 272.44
- A1170: Expenses: Transporte de material de préstamo cantera de rio (cuerpo de terraplén) D>1km - (cost) 272.44
- A1200: Expenses: Transporte de roca D<=1km - (cost) 272.44
- A1210: Expenses: Transporte de roca D>1km - (cost) 272.44
- A1390: Expenses: Concreto de Nivelacion (f'c=100 kg/cm2) - (cost) 272.44
- A1400: Expenses: Concreto Ciclópeo (f'c=280 kg/cm2) + 30%PG. - (cost) 272.44
- A1410: Expenses: Encofrado y Desencofrado Caravista - (cost) 272.44
- A1420: Expenses: Encofrado y Desencofrado Cara Oculta - (cost) 272.44
- A1430: Expenses: Acero de refuerzo f'y=4200kg/cm2 - (cost) 272.44
- A1440: Expenses: Concreto Clase C (f'c=280 kg/cm2) Premezclado - Cimientos reforzados - (cost) 272.44
- A1450: Expenses: Concreto Clase C (f'c=280 kg/cm2) Premezclado - Muros de contención - (cost) 272.44
- A1460: Expenses: Pintura Bituminosa - (cost) 272.44
- A1470: Expenses: Tubo PVC - D=6'' - (cost) 272.44
- A1480: Expenses: Geocompuesto de Drenaje - (cost) 272.44
- A1490: Expenses: Tubo PVC - D=4'' - (cost) 272.44

| ID | WBS | Activity | Type | Duration | Start | Finish | Predecessors | Total float | Free float | Resources | Cost |
| --- | --- | --- | --- | --- | --- | --- | --- | --- | --- | --- | --- |
|  | 1 | **Relleno** |  |  | 2025-06-27 | 2025-07-30 |  |  |  |  |  |
| A2590 |  | Relleno con material granular (incluye extracción de material, zarandeo y combinación de material) |  | 10d | 2025-06-27 | 2025-07-09 | A1450 SS+25d | -0.28d | 0d | TRACTOR SOBRE ORUGAS CAT D6D [90 h]; RODILLO LISO VIBRATORIO AUTOPROPULSADO 101-135 HP 10-12TON [90 h] | 272.44 |
| A2620 |  | Transporte de material de relleno para muro |  | 28d | 2025-06-27 | 2025-07-30 | A1450 SS+25d | -0.28d | 0d |  |  |
| A2600 |  | Relleno con material seleccionado (incluye extracción de material, zarandeo y combinación de material) en Sobreexcavació |  | 17d | 2025-07-02 | 2025-07-22 | A2590 SS+4d | -0.28d | 0d | EXCAVADORA CAT 336 [459 h]; RODILLO LISO VIBRATORIO AUTOPROPULSADO 101-135 HP 10-12TON [459 h] | 272.44 |
| A2630 |  | Perfilado de Talud del dique |  | 10d | 2025-07-07 | 2025-07-18 | A2600 SS+4d | -0.28d | 0d | EXCAVADORA CAT 336 [27 h] | 272.44 |
| A2640 |  | Relleno Material Propio compactado |  | 10d | 2025-07-18 | 2025-07-30 | A2600 FF, A2630 | -0.28d | 0d | RODILLO LISO VIBRATORIO MANUAL 10.8 HP 0.8 -1.1 Ton [90 h]; RETROEXCAVADORA SOBRE LLANTAS 58 HP, 1 Y3 [45 h] | 272.44 |
| A2750 |  | Fin de Relleno | milestone | 0d | 2025-07-30 | 2025-07-30 | A2600, A2620 FF | -0.28d | 0d |  |  |
|  | 3 | **INFRAESTRUCTURA VERDE Y PAISAJISMO** |  |  | 2024-04-05 | 2025-07-21 |  |  |  |  |  |
| A2800 |  | Entrega de Terreno Liberado |  | 0d | 2024-04-05 | 2024-04-05 | A1540 FS+30d | 8.22d | 0d |  |  |
| A2810 |  | Inicio de obras |  | 0d | 2024-04-12 | 2024-04-12 | A2800 FS+6d | 8.22d | 0d |  |  |
| A2820 |  | Fin obras | milestone | 0d | 2025-07-19 | 2025-07-19 | A1620 | 9.11d | 9.39d |  |  |
|  | 1 | **Infraestructura Verde y Paisajismo** |  |  | 2024-04-12 | 2025-07-21 |  |  |  |  |  |
| A2830 |  | Revegetación / reforestación de la ribera |  | 398d | 2024-04-12 | 2025-07-19 | A2810 | 8.22d | 0d |  |  |
| A2840 |  | Infraestructura Paisajística en Alameda de Sayán |  | 398d | 2024-04-12 | 2025-07-19 | A2810 | 8.22d | 0d |  |  |
| A2850 |  | Pozo De Infiltración |  | 398d | 2024-04-12 | 2025-07-19 | A2810 | 8.22d | 0d |  |  |
| A2860 |  | Obras De Concreto Armado |  | 398d | 2024-04-12 | 2025-07-19 | A2810 | 8.22d | 0d |  |  |
| A2870 |  | Instalaciones Sanitarias |  | 398d | 2024-04-12 | 2025-07-19 | A2810 | 8.22d | 0d |  |  |
| A2880 |  | Iluminación De Espacio Público |  | 398d | 2024-04-12 | 2025-07-19 | A2810 | 8.22d | 0d |  |  |
| A2890 |  | Otros |  | 398d | 2024-04-12 | 2025-07-19 | A2810 | 8.22d | 0d |  |  |
| A2900 |  | Fin de Infraestructura y Paisajismo |  | 0d | 2025-07-21 | 2025-07-21 | A2830, A2840, A2850, A2860, A2870, A2880, A2890 | 8.22d | 8.5d |  |  |
|  | 2 | **CIERRE DE OBRA** |  |  | 2025-07-30 | 2025-07-30 |  |  |  |  |  |
| A2430 |  | Fin de Obras |  | 0d | 2025-07-30 | 2025-07-30 | A1460 | -0.28d | 0d |  |  |

Notes:
- A2590: Expenses: Relleno con material granular (incluye extracción de material, zarandeo y combinación de material) - (cost) 272.44
- A2600: Expenses: Relleno con material seleccionado (incluye extracción de material, zarandeo y combinación de material) en Sobreexcavació 272.44
- A2630: Expenses: Perfilado de Talud del dique - (cost) 272.44
- A2640: Expenses: Relleno Material Propio compactado - (cost) 272.44
